# Тема7

Schedule from MS Project, 2009-09-07 to 2009-11-16, costs in р..
ТИУиЭ

## Calendars

- Стандартный: Mon-Fri 09:00-13:00, 14:00-18:00; Sat-Sun off. Exceptions (off unless hours are given): 2009-11-04 (День согласия и примирения).

## Resources

| Resource | Unit | Rate |
| --- | --- | --- |
| Постановщик |  | 312.5 |
| Программист1 |  | 406.25 |
| Программист2 |  | 437.5 |
| Бумага | пачка | 200 |
| Междугородные переговоры |  |  |
| CD-матрица | штука | 10 |

## Schedule

| ID | WBS | Task | Type | Duration | Start | Finish | Predecessors | Total slack | Free slack | Constraint | Deadline | Resources | Work | Cost |
| --- | --- | --- | --- | --- | --- | --- | --- | --- | --- | --- | --- | --- | --- | --- |
| 1 | 1 | Начало реализации проекта | milestone | 0d | 2009-09-07 | 2009-09-07 |  | 0d |  |  |  |  |  |  |
| 2 | 2 | **Программирование** |  | 34d | 2009-09-07 | 2009-10-22 |  | -9d | 0d |  |  |  | 288h | 26,220 |
| 3 | 2.1 | Постановка задачи |  | 16d | 2009-09-07 | 2009-10-01 | 1 | -9d | 0d |  |  | Постановщик; Бумага [1 пачка]; CD-матрица [0.03 штука]; Междугородные переговоры [0.2%] | 80h | 26,220 |
| 4 | 2.2 | Разработка интерфейса |  | 5d | 2009-10-02 | 2009-10-08 | 3 | -4d | 0d |  |  | Программист1; CD-матрица [0.12 штука]; Междугородные переговоры [0.1%] | 40h |  |
| 5 | 2.3 | Разработка модулей обработки данных |  | 6d | 2009-10-13 | 2009-10-20 | 4, 6 | -6d | 0d |  |  | Программист1; CD-матрица [0.12 штука] | 48h |  |
| 6 | 2.4 | Разработка структуры базы данных |  | 7d | 2009-10-02 | 2009-10-12 | 3 | -8d | 0d |  |  | Программист2; CD-матрица [0.12 штука]; Междугородные переговоры [0.3%] | 56h |  |
| 7 | 2.5 | Заполнение базы данных |  | 8d | 2009-10-13 | 2009-10-22 | 6 | -8d | 0d |  |  | Программист2; CD-матрица [0.12 штука] | 64h |  |
| 8 | 2.6 | Программирование завершено | milestone | 0d | 2009-10-22 | 2009-10-22 | 5, 7 | -8d | 0d |  |  |  |  |  |
| 9 | 3 | **Отладка** |  | 16d | 2009-10-23 | 2009-11-16 |  | -8d | 0d |  |  |  | 400h |  |
| 10 | 3.1 | Отладка программного комплекса |  | 6d | 2009-10-23 | 2009-11-02 | 8 | -9d | 0d |  |  | Постановщик; Программист1; Программист2; CD-матрица [0.25 штука] | 120h |  |
| 11 | 3.2 | Тестирование и исправление ошибок |  | 12d | 2009-10-28 | 2009-11-16 | 10 | -5d | 0d | finish no later than 2009-11-16 | 2009-11-09 | Постановщик; Программист1; Программист2; CD-матрица [0.25 штука] | 240h |  |
| 12 | 3.3 | Составление программной документации |  | 5d | 2009-11-09 | 2009-11-16 | 10 | 0d |  | as late as possible |  | Постановщик; CD-матрица [10 штука]; Междугородные переговоры [0.6%] | 40h |  |
| 13 | 3.4 | Отладка завершена | milestone | 0d | 2009-11-16 | 2009-11-16 | 11, 12 | 0d |  |  |  |  |  |  |
| 14 | 4 | Конец проекта | milestone | 0d | 2009-11-16 | 2009-11-16 | 13 | 0d |  |  |  |  |  |  |
